# AET_MS2007

Schedule from MS Project, 2010-03-01 to 2010-05-04.
osu

## Calendars

- Standard: Mon-Sun 08:00-12:00, 13:00-17:00.

## Schedule

| ID | WBS | Task | Duration | Start | Finish | Predecessors | Total slack | Free slack |
| --- | --- | --- | --- | --- | --- | --- | --- | --- |
| 1 | 1 | **AET DATA CENTER MIGRATION** | 65d | 2010-03-01 | 2010-05-04 |  | 0d |  |
| 2 | 1.1 | Team Meeting | 1d | 2010-03-01 | 2010-03-01 |  | 0d |  |
| 3 | 1.2 | Hire Contractors | 7d | 2010-03-02 | 2010-03-08 | 2 | 23d | 7d |
| 4 | 1.3 | Network Design | 14d | 2010-03-02 | 2010-03-15 | 2 | 16d | 0d |
| 5 | 1.4 | **Ventilation System** | 28d | 2010-03-02 | 2010-03-29 |  | 7d |  |
| 6 | 1.4.1 | Order Ventilation System | 21d | 2010-03-02 | 2010-03-22 | 2 | 7d | 0d |
| 7 | 1.4.2 | Install Ventilation System | 7d | 2010-03-23 | 2010-03-29 | 6 | 7d |  |
| 8 | 1.5 | **New Racks** | 35d | 2010-03-02 | 2010-04-05 |  | 0d |  |
| 9 | 1.5.1 | Order New Racks | 14d | 2010-03-02 | 2010-03-15 | 2 | 0d |  |
| 10 | 1.5.2 | Install Racks | 21d | 2010-03-16 | 2010-04-05 | 9 | 0d |  |
| 11 | 1.6 | **Power Supplies and Cables** | 44d | 2010-03-02 | 2010-04-14 |  | 6d |  |
| 12 | 1.6.1 | Order Power Supplies & Cables | 7d | 2010-03-02 | 2010-03-08 | 2 | 30d |  |
| 13 | 1.6.2 | Install Power Supplies | 5d | 2010-04-08 | 2010-04-12 | 16, 12 | 8d | 2d |
| 14 | 1.6.3 | Install Cables | 7d | 2010-04-08 | 2010-04-14 | 16, 12 | 0d |  |
| 15 | 1.7 | Renovation of Data Center | 20d | 2010-03-16 | 2010-04-04 | 3, 4 | 16d | 10d |
| 16 | 1.8 | City Inspection | 2d | 2010-04-06 | 2010-04-07 | 3, 7, 10 | 0d |  |
| 17 | 1.9 | **Switchover Meetings** | 7d | 2010-04-15 | 2010-04-21 |  | 0d |  |
| 18 | 1.9.1 | Facilities | 7d | 2010-04-15 | 2010-04-21 | 14 | 0d |  |
| 19 | 1.9.2 | Operations/Systems | 7d | 2010-04-15 | 2010-04-21 | 14 | 0d |  |
| 20 | 1.9.3 | Operations/Telecommunications | 7d | 2010-04-15 | 2010-04-21 | 14 | 0d |  |
| 21 | 1.9.4 | Systems & Applications | 7d | 2010-04-15 | 2010-04-21 | 14 | 0d |  |
| 22 | 1.9.5 | Customer Service | 7d | 2010-04-15 | 2010-04-21 | 14 | 0d |  |
| 23 | 1.10 | Power Check | 1d | 2010-04-15 | 2010-04-15 | 14, 13, 15 | 6d |  |
| 24 | 1.11 | Install Test Servers | 7d | 2010-04-22 | 2010-04-28 | 23, 18, 19, 20, 21, 22 | 0d |  |
| 25 | 1.12 | Management Safety Check | 2d | 2010-04-29 | 2010-04-30 | 23, 7, 24 | 0d |  |
| 26 | 1.13 | Primary Systems Check | 1d | 2010-05-01 | 2010-05-01 | 25 | 0d |  |
| 27 | 1.14 | Set Date for Move | 1d | 2010-05-02 | 2010-05-02 | 26 | 0d |  |
| 28 | 1.15 | Complete Move | 2d | 2010-05-03 | 2010-05-04 | 27 | 0d |  |
