# Blue_Zuma_P2A

Schedule from MS Project, 2008-01-02 to 2009-02-24, status date 2008-08-15, costs in $, A marks actual dates.
Home

## Calendars

- Standard: Mon-Fri 08:00-12:00, 13:00-17:00; Sat-Sun off. Exceptions (off unless hours are given): 2008-05-26, 2008-07-04, 2008-09-01, 2008-11-27, 2008-12-25 to 2008-12-26, 2009-01-01.

## Resources

| Resource | Rate |
| --- | --- |
| Marketing specialist | 60 |
| Design engineer | 90 |
| Development engineer | 80 |
| Industrial engineer | 70 |
| Purchasing agent | 50 |
| Industiral engineer (extra) | 80 |
| Development engineer (extra) | 90 |
| Design engineer (extra) | 100 |

## Schedule

| ID | WBS | Task | Duration | Start | Finish | Predecessors | Complete | Remaining | Baseline start | Baseline finish | Baseline duration | Total slack | Constraint | Resources | Work | Actual work | Cost | Baseline cost | Actual cost |
| --- | --- | --- | --- | --- | --- | --- | --- | --- | --- | --- | --- | --- | --- | --- | --- | --- | --- | --- | --- |
| 1 | 1 | **Blue Zuma Project** | 293d | 2008-01-02 A | 2009-02-24 |  | 60% | 116.79d | 2008-01-02 | 2009-01-28 | 274d | 0d |  |  | 18188h | 11844h | 1,392,280 | 1,260,000 | 916,600 |
| 2 | 1.1 | Market analysis | 23d | 2008-01-02 A | 2008-02-01 A |  | 100% |  | 2008-01-02 | 2008-02-05 | 25d |  |  | Marketing specialist [400%] | 736h | 736h | 44,160 | 48,000 | 44,160 |
| 3 | 1.2 | Product design | 34d | 2008-02-04 A | 2008-03-20 A | 2 | 100% |  | 2008-02-06 | 2008-04-01 | 40d |  |  | Marketing specialist; Design engineer [400%]; Development engineer [200%]; Industrial engineer; Purchasing agent | 2448h | 2448h | 190,400 | 224,000 | 190,400 |
| 4 | 1.3 | Manufacturing study | 23d | 2008-03-21 A | 2008-04-22 A | 2 | 100% |  | 2008-04-02 | 2008-04-29 | 20d |  |  | Industrial engineer [400%]; Development engineer [200%] | 1104h | 1104h | 80,960 | 70,400 | 80,960 |
| 5 | 1.4 | Product design selection | 15d | 2008-04-23 A | 2008-05-13 A | 3, 4 | 100% |  | 2008-04-30 | 2008-05-13 | 10d |  |  | Marketing specialist [200%]; Design engineer [300%]; Development engineer [200%]; Industrial engineer [200%]; Purchasing agent [25%] | 1110h | 1110h | 84,300 | 56,200 | 84,300 |
| 6 | 1.5 | Detailed marketing plan | 15d | 2008-07-25 | 2008-08-14 | 5 |  |  | 2008-07-25 | 2008-08-14 | 15d | 132d |  | Marketing specialist [400%] | 480h |  | 28,800 | 28,800 |  |
| 7 | 1.6 | Manufacturing process | 36d | 2008-08-01 A | 2008-09-22 | 5 | 31% | 25d | 2008-07-15 | 2008-08-25 | 30d | 0d | start no earlier than 2008-07-15 | Design engineer; Development engineer [200%]; Industrial engineer [400%] | 2016h | 616h | 152,640 | 127,200 | 46,640 |
| 8 | 1.7 | Detailed product design | 55d | 2008-05-14 A | 2008-07-31 A | 5 | 100% |  | 2008-05-14 | 2008-07-14 | 42d |  |  | Marketing specialist [200%]; Design engineer [400%]; Development engineer [200%]; Industrial engineer [200%]; Purchasing agent [25%]; Development engineer (extra); Design engineer (extra) | 5390h | 5390h | 432,300 | 330,120 | 432,300 |
| 9 | 1.8 | Test prototype | 11d | 2008-08-01 A | 2008-08-15 A | 8 | 100% |  | 2008-07-15 | 2008-07-28 | 10d |  |  | Design engineer [300%]; Development engineer [200%] | 440h | 440h | 37,840 | 34,400 | 37,840 |
| 10 | 1.9 | Finalized product design | 25d | 2008-09-23 | 2008-10-27 | 7, 9 |  |  | 2008-08-26 | 2008-09-30 | 25d | 0d |  | Marketing specialist [200%]; Design engineer [300%]; Development engineer [300%]; Industrial engineer [200%] | 2000h |  | 154,000 | 154,000 |  |
| 11 | 1.10 | Order components | 7d | 2008-10-28 | 2008-11-05 | 10 |  |  | 2008-10-21 | 2008-10-29 | 7d | 27d | start no earlier than 2008-10-21 | Purchasing agent | 56h |  | 2,800 | 2,800 |  |
| 12 | 1.11 | Order production equipment | 14d | 2008-10-28 | 2008-11-14 | 10 |  |  | 2008-10-01 | 2008-10-20 | 14d | 0d |  | Purchasing agent | 112h |  | 5,600 | 5,600 |  |
| 13 | 1.12 | Install production equipment | 27d | 2009-01-16 | 2009-02-23 | 11FS+20d, 12FS+40d |  |  | 2008-12-17 | 2009-01-27 | 27d | 0d |  | Development engineer [300%]; Industrial engineer [400%]; Design engineer; Industiral engineer (extra); Development engineer (extra) | 2160h |  | 168,480 | 168,480 |  |
| 14 | 1.13 | Celebrate | 1d | 2009-02-24 | 2009-02-24 | 6, 13 |  |  | 2009-01-28 | 2009-01-28 | 1d | 0d |  | Development engineer [400%]; Industrial engineer [400%]; Design engineer [400%]; Marketing specialist [400%]; Purchasing agent | 136h |  | 10,000 | 10,000 |  |
