# Blue_Zuma_Project_Part3

Schedule from MS Project, 2008-01-02 to 2009-01-28, costs in $.

## Calendars

- Standard: Mon-Fri 08:00-12:00, 13:00-17:00; Sat-Sun off. Exceptions (off unless hours are given): 2008-05-26 (Memorial Day), 2008-07-04 (July 4th), 2008-09-01 (Labor Day), 2008-11-27 (Thanksgiving), 2008-12-25 to 2008-12-26 (Christmas), 2009-01-01 (New Year).

## Resources

| Resource | Rate |
| --- | --- |
| Marketing Specialist | 60 |
| Design Engineer | 90 |
| Development Engineer | 80 |
| Industrial Engineer | 70 |
| Purchasing Agent | 50 |
| Industrial Engineer X | 80 |
| Development Engineer X | 90 |
| Design Engineer X | 100 |

## Schedule

| ID | WBS | Task | Duration | Start | Finish | Predecessors | Total slack | Free slack | Constraint | Resources | Work | Cost |
| --- | --- | --- | --- | --- | --- | --- | --- | --- | --- | --- | --- | --- |
| 1 | 1 | **Product Development Project** | 274d | 2008-01-02 | 2009-01-28 |  | 0d |  |  |  | 16280h | 1,243,200 |
| 2 | 1.1 | Market Analysis | 25d | 2008-01-02 | 2008-02-05 |  | 20d | 0d |  | Marketing Specialist [400%] | 800h | 48,000 |
| 3 | 1.2 | Product Design | 40d | 2008-02-06 | 2008-04-01 | 2 | 40d | 20d |  | Marketing Specialist; Design Engineer [400%]; Development Engineer [200%]; Industrial Engineer; Purchasing Agent | 2880h | 224,000 |
| 4 | 1.3 | Manufacturing Study | 20d | 2008-04-02 | 2008-04-29 | 2 | 20d | 0d |  | Industrial Engineer [400%]; Development Engineer [200%] | 960h | 70,400 |
| 5 | 1.4 | Product Design Selection | 10d | 2008-04-30 | 2008-05-13 | 3, 4 | 20d | 0d |  | Marketing Specialist [200%]; Design Engineer [300%]; Development Engineer [200%]; Industrial Engineer [200%]; Purchasing Agent [25%] | 740h | 56,200 |
| 6 | 1.5 | Detailed Marketing Plan | 15d | 2008-07-25 | 2008-08-14 | 5 | 113d |  |  | Marketing Specialist [400%] | 480h | 28,800 |
| 7 | 1.6 | Manufacturing Process | 30d | 2008-07-15 | 2008-08-25 | 5 | 0d |  | start no earlier than 2008-07-15 | Design Engineer; Development Engineer [200%]; Industrial Engineer [300%] | 1440h | 110,400 |
| 8 | 1.7 | Detailed Product Design | 42d | 2008-05-14 | 2008-07-14 | 5 | 20d | 0d |  | Marketing Specialist [200%]; Design Engineer [400%]; Development Engineer [200%]; Industrial Engineer [200%]; Purchasing Agent [25%]; Development Engineer X; Design Engineer X | 4116h | 330,120 |
| 9 | 1.8 | Test Prototype | 10d | 2008-07-15 | 2008-07-28 | 8 | 20d |  |  | Design Engineer [300%]; Development Engineer [200%] | 400h | 34,400 |
| 10 | 1.9 | Finalized Product Design | 25d | 2008-08-26 | 2008-09-30 | 7, 9 | 0d |  |  | Marketing Specialist [200%]; Design Engineer [300%]; Development Engineer [300%]; Industrial Engineer [200%] | 2000h | 154,000 |
| 11 | 1.10 | Order Components | 7d | 2008-10-20 | 2008-10-28 | 10 | 14d |  |  | Purchasing Agent | 56h | 2,800 |
| 12 | 1.11 | Order Production Equipment | 14d | 2008-10-01 | 2008-10-20 | 10 | 0d |  |  | Purchasing Agent | 112h | 5,600 |
| 13 | 1.12 | Install Production Equipment | 27d | 2008-12-17 | 2009-01-27 | 11FS+20d, 12FS+40d | 0d |  |  | Development Engineer [300%]; Industrial Engineer [400%]; Design Engineer; Industrial Engineer X; Development Engineer X | 2160h | 168,480 |
| 14 | 1.13 | Celebrate | 1d | 2009-01-28 | 2009-01-28 | 6, 13 | 0d |  |  | Development Engineer [400%]; Industrial Engineer [400%]; Design Engineer [400%]; Marketing Specialist [400%]; Purchasing Agent | 136h | 10,000 |
